# 2010 Support Pack Implementation Project

How a schedule from MS Project changed from version to version. A marks actual dates.

## Version 1 (saved 2011-02-03)

| ID | WBS | Task | Duration | Start | Finish | Predecessors | Complete | Total float | Constraint |
| --- | --- | --- | --- | --- | --- | --- | --- | --- | --- |
| 1 | 1 | **Project Preparation & Planning** | 77d | 2010-08-23 08:00 A | 2010-12-07 17:00 A |  | 100% |  |  |
| 2 | 1.1 | **Appoint project team, define roles and responsibilities** | 9.12d | 2010-08-23 08:00 A | 2010-09-03 09:00 A |  | 100% |  |  |
| 3 |  | Appoint project manager | 1h | 2010-08-23 08:00 A | 2010-08-23 09:00 A |  | 100% |  |  |
| 4 |  | Define project team, member roles and responsibilities | 1d | 2010-08-24 09:00 A | 2010-08-25 09:00 A | 3FS+1d | 100% |  |  |
| 5 |  | Appoint project team members (core team/testing coordinators/extended team, etc …) | 3d | 2010-08-25 09:00 A | 2010-08-30 09:00 A | 4 | 100% |  |  |
| 6 |  | Notify project team members of their role | 1d | 2010-08-31 09:00 A | 2010-09-01 09:00 A | 5FS+1d | 100% |  |  |
| 7 |  | Update business owner list with new / changed owners | 1d | 2010-09-02 09:00 A | 2010-09-03 09:00 A | 6FS+1d | 100% |  |  |
| 8 | 1.2 | **Develop Project Plan** | 19.21d | 2010-08-23 09:00 A | 2010-09-17 10:40 A | 3 | 100% |  |  |
| 9 |  | Determine support package availability date | 1d | 2010-08-23 09:00 A | 2010-08-24 09:00 A |  | 100% |  |  |
| 10 |  | Determine desired support package & enhancement package levels | 1d | 2010-08-24 09:00 A | 2010-08-25 09:00 A | 9 | 100% |  |  |
| 11 |  | Determine dates for production freeze | 1d | 2010-09-01 10:40 A | 2010-09-02 10:40 A | 15 | 100% |  |  |
| 12 |  | Define high level plan, milestones, deliverables | 5d | 2010-09-02 10:40 A | 2010-09-09 10:40 A | 11 | 100% |  |  |
| 13 |  | Identify Pending Projects that may collide with the project | 1d | 2010-09-09 10:40 A | 2010-09-10 10:40 A | 12 | 100% |  |  |
| 14 |  | Review any development/cleanup work that can be included in the project | 5d | 2010-09-10 10:40 A | 2010-09-17 10:40 A | 13 | 100% |  |  |
| 15 | 1.3 | **Define environments, refresh schedule, support pack plan** | 2.21d | 2010-08-30 09:00 A | 2010-09-01 10:40 A |  | 100% |  |  |
| 16 |  | Identify environments for Staging, and TST (DEV not refreshed) | 1h | 2010-08-30 09:00 A | 2010-08-30 10:00 A | 5 | 100% |  |  |
| 17 |  | Develop/update env landscape document | 1h | 2010-08-30 10:00 A | 2010-08-30 11:00 A | 16 | 100% |  |  |
| 18 |  | Determine production snapshot dates for STG, TST | 1h | 2010-09-01 09:00 A | 2010-09-01 10:00 A | 6 | 100% |  |  |
| 19 |  | Determine dates for STG, TST refreshes | 1h | 2010-09-01 09:00 A | 2010-09-01 10:00 A | 6 | 100% |  |  |
| 20 |  | Plan datawarehouse extracts | 0.67h | 2010-09-01 10:00 A | 2010-09-01 10:40 A | 19 | 100% |  |  |
| 21 | 1.4 | **Develop cut-over plan** | 24d | 2010-11-04 08:00 A | 2010-12-07 17:00 A | 199 | 100% |  |  |
| 22 |  | Identify resources | 1d | 2010-11-04 08:00 A | 2010-11-04 17:00 A |  | 100% |  |  |
| 23 |  | Prep cut-over plan document | 4h | 2010-11-04 08:00 A | 2010-11-04 12:00 A |  | 100% |  |  |
| 24 |  | Review transports resulting from SPAU | 4h | 2010-11-04 08:00 A | 2010-11-04 12:00 A |  | 100% |  |  |
| 25 |  | Review transports resulting from Unit Test | 4h | 2010-11-11 08:00 A | 2010-11-11 12:00 A | 218 | 100% |  |  |
| 26 |  | Review transports resulting from SIT/UAT | 4h | 2010-12-07 08:00 A | 2010-12-07 12:00 A | 261 | 100% |  |  |
| 27 |  | Schedule cut-over plan meeting | 1h | 2010-11-11 13:00 A | 2010-11-11 14:00 A | 25 | 100% |  |  |
| 28 |  | Cut-over plan meeting | 2h | 2010-11-11 14:00 A | 2010-11-11 16:00 A | 27 | 100% |  |  |
| 29 |  | Develop cut-over plan & publish | 9d | 2010-11-11 16:00 A | 2010-11-24 16:00 A | 28 | 100% |  |  |
| 30 |  | Finalize cut-over plan & publish | 4h | 2010-12-07 13:00 A | 2010-12-07 17:00 A | 26 | 100% |  |  |
| 31 | 2 | **Communication** | 112.25d | 2010-08-23 08:00 A | 2011-01-26 10:00 |  | 99% | 3.88d |  |
| 32 |  | Develop project wiki | 5d | 2010-08-25 09:00 A | 2010-09-01 09:00 A | 3FS+2d | 100% |  |  |
| 33 |  | Schedule IS&T (Admin Systems) project kick-off meeting | 2h | 2010-08-23 08:00 A | 2010-08-23 10:00 A |  | 100% |  |  |
| 34 |  | Schedule SAPbiz project kick-off meeting (last meeting of September) | 1h | 2010-08-25 09:00 A | 2010-08-25 10:00 A | 3FS+2d | 100% |  |  |
| 35 |  | Schedule Steering Committee Meeting | 1d | 2010-08-27 09:00 A | 2010-08-30 09:00 A | 3FS+4d | 100% |  |  |
| 36 |  | Schedule Core Team Meeting(s) | 1d | 2010-09-02 09:00 A | 2010-09-03 09:00 A | 6FS+1d | 100% |  |  |
| 37 |  | Review/update communication email list sa-upgrade-core@mit.edu | 1h | 2010-09-03 09:00 A | 2010-09-03 10:00 A | 7 | 100% |  |  |
| 38 |  | Review/update communication email list ist-sap@mit.edu | 1h | 2010-09-03 10:00 A | 2010-09-03 11:00 A | 37 | 100% |  |  |
| 39 |  | Prepare Project Presentation for the Steering Committee | 2d | 2010-08-30 09:00 A | 2010-09-01 09:00 A | 35 | 100% |  |  |
| 40 |  | Prepare Project Presentation for IS&T | 2d | 2010-09-03 13:00 A | 2010-09-07 12:00 A | 39 | 100% |  |  |
| 41 |  | Prepare Project Presentation for SAPbiz | 2d | 2010-09-07 13:00 A | 2010-09-09 12:00 A | 40 | 100% |  |  |
| 42 |  | IS&T Kick off meeting | 2h | 2010-09-09 10:40 A | 2010-09-09 13:40 A | 12 | 100% |  |  |
| 43 |  | Review/update communication email list sap-vailidation-team@mit.edu | 1h | 2010-12-02 08:00 A | 2010-12-02 09:00 A | 253SS+15d | 100% |  |  |
| 44 | 2.13 | **Steering Committee Meeting** | 85.12d | 2010-09-06 08:00 A | 2011-01-03 09:00 A |  | 100% |  |  |
| 45 |  | Steering Committee Meeting 1 | 1h | 2010-09-06 08:00 A | 2010-09-06 09:00 A |  | 100% |  | start no earlier than 2010-09-06 08:00 |
| 46 |  | Steering Committee Meeting 2 | 1h | 2010-10-04 08:00 A | 2010-10-04 09:00 A |  | 100% |  | start no earlier than 2010-10-04 08:00 |
| 47 |  | Steering Committee Meeting 3 | 1h | 2010-11-01 08:00 A | 2010-11-01 09:00 A |  | 100% |  | start no earlier than 2010-11-01 08:00 |
| 48 |  | Steering Committee Meeting 4 | 1h | 2010-12-06 08:00 A | 2010-12-06 09:00 A |  | 100% |  | start no earlier than 2010-12-06 08:00 |
| 49 |  | Steering Committee Meeting 5 | 1h | 2011-01-03 08:00 A | 2011-01-03 09:00 A |  | 100% |  | start no earlier than 2011-01-03 08:00 |
| 50 | 2.14 | **Core Team Meeting** | 70.12d | 2010-09-13 08:00 A | 2010-12-20 09:00 A |  | 100% |  |  |
| 51 |  | Core Team Meeting 1 | 1h | 2010-09-13 08:00 A | 2010-09-13 09:00 A |  | 100% |  | start no earlier than 2010-09-13 08:00 |
| 52 |  | Core Team Meeting 2 | 1h | 2010-09-20 08:00 A | 2010-09-20 09:00 A |  | 100% |  | start no earlier than 2010-09-20 08:00 |
| 53 |  | Core Team Meeting 3 | 1h | 2010-09-27 08:00 A | 2010-09-27 09:00 A |  | 100% |  | start no earlier than 2010-09-27 08:00 |
| 54 |  | Core Team Meeting 4 | 1h | 2010-10-04 08:00 A | 2010-10-04 09:00 A |  | 100% |  | start no earlier than 2010-10-04 08:00 |
| 55 |  | Core Team Meeting 5 | 1h | 2010-10-11 08:00 A | 2010-10-11 09:00 A |  | 100% |  | start no earlier than 2010-10-11 08:00 |
| 56 |  | Core Team Meeting 6 | 1h | 2010-10-18 08:00 A | 2010-10-18 09:00 A |  | 100% |  | start no earlier than 2010-10-18 08:00 |
| 57 |  | Core Team Meeting 7 | 1h | 2010-10-25 08:00 A | 2010-10-25 09:00 A |  | 100% |  | start no earlier than 2010-10-25 08:00 |
| 58 |  | Core Team Meeting 8 | 1h | 2010-11-01 08:00 A | 2010-11-01 09:00 A |  | 100% |  | start no earlier than 2010-11-01 08:00 |
| 59 |  | Core Team Meeting 9 | 1h | 2010-11-08 08:00 A | 2010-11-08 09:00 A |  | 100% |  | start no earlier than 2010-11-08 08:00 |
| 60 |  | Core Team Meeting 10 | 1h | 2010-11-15 08:00 A | 2010-11-15 09:00 A |  | 100% |  | start no earlier than 2010-11-15 08:00 |
| 61 |  | Core Team Meeting 11 | 1h | 2010-11-22 08:00 A | 2010-11-22 09:00 A |  | 100% |  | start no earlier than 2010-11-22 08:00 |
| 62 |  | Core Team Meeting 12 | 1h | 2010-11-29 08:00 A | 2010-11-29 09:00 A |  | 100% |  | start no earlier than 2010-11-29 08:00 |
| 63 |  | Core Team Meeting 13 | 1h | 2010-12-06 08:00 A | 2010-12-06 09:00 A |  | 100% |  | start no earlier than 2010-12-06 08:00 |
| 64 |  | Core Team Meeting 14 | 1h | 2010-12-13 08:00 A | 2010-12-13 09:00 A |  | 100% |  | start no earlier than 2010-12-13 08:00 |
| 65 |  | Core Team Meeting 15 | 1h | 2010-12-20 08:00 A | 2010-12-20 09:00 A |  | 100% |  | start no earlier than 2010-12-20 08:00 |
| 66 | 2.15 | **SAPbiz Meeting** | 90.25d | 2010-09-22 08:00 A | 2011-01-26 10:00 |  | 80% | 3.88d |  |
| 67 |  | SAPbiz Meeting 1 | 2h | 2010-09-22 08:00 A | 2010-09-22 10:00 A |  | 100% |  | start no earlier than 2010-09-22 08:00 |
| 68 |  | SAPbiz Meeting 2 | 2h | 2010-10-27 08:00 A | 2010-10-27 10:00 A |  | 100% |  | start no earlier than 2010-10-27 08:00 |
| 69 |  | SAPbiz Meeting 3 | 2h | 2010-11-24 08:00 A | 2010-11-24 10:00 A |  | 100% |  | start no earlier than 2010-11-24 08:00 |
| 70 |  | SAPbiz Meeting 4 | 2h | 2010-12-22 08:00 A | 2010-12-22 10:00 A |  | 100% |  | start no earlier than 2010-12-22 08:00 |

| ID | WBS | Task | Duration | Start | Finish | Predecessors | Complete | Total float | Constraint |
| --- | --- | --- | --- | --- | --- | --- | --- | --- | --- |
| 71 |  | SAPbiz Meeting 5 | 2h | 2011-01-26 08:00 | 2011-01-26 10:00 |  |  | 3.88d | start no earlier than 2011-01-26 08:00 |
| 72 | 2.16 | **R3 Admin Meeting** | 105.12d | 2010-08-27 08:00 A | 2011-01-21 09:00 A |  | 100% |  |  |
| 73 |  | R3 Admin Meeting 1 | 1h | 2010-08-27 08:00 A | 2010-08-27 09:00 A |  | 100% |  | start no earlier than 2010-08-27 08:00 |
| 74 |  | R3 Admin Meeting 2 | 1h | 2010-09-03 08:00 A | 2010-09-03 09:00 A |  | 100% |  | start no earlier than 2010-09-03 08:00 |
| 75 |  | R3 Admin Meeting 3 | 1h | 2010-09-10 08:00 A | 2010-09-10 09:00 A |  | 100% |  | start no earlier than 2010-09-10 08:00 |
| 76 |  | R3 Admin Meeting 4 | 1h | 2010-09-17 08:00 A | 2010-09-17 09:00 A |  | 100% |  | start no earlier than 2010-09-17 08:00 |
| 77 |  | R3 Admin Meeting 5 | 1h | 2010-09-24 08:00 A | 2010-09-24 09:00 A |  | 100% |  | start no earlier than 2010-09-24 08:00 |
| 78 |  | R3 Admin Meeting 6 | 1h | 2010-10-01 08:00 A | 2010-10-01 09:00 A |  | 100% |  | start no earlier than 2010-10-01 08:00 |
| 79 |  | R3 Admin Meeting 7 | 1h | 2010-10-08 08:00 A | 2010-10-08 09:00 A |  | 100% |  | start no earlier than 2010-10-08 08:00 |
| 80 |  | R3 Admin Meeting 8 | 1h | 2010-10-15 08:00 A | 2010-10-15 09:00 A |  | 100% |  | start no earlier than 2010-10-15 08:00 |
| 81 |  | R3 Admin Meeting 9 | 1h | 2010-10-22 08:00 A | 2010-10-22 09:00 A |  | 100% |  | start no earlier than 2010-10-22 08:00 |
| 82 |  | R3 Admin Meeting 10 | 1h | 2010-10-29 08:00 A | 2010-10-29 09:00 A |  | 100% |  | start no earlier than 2010-10-29 08:00 |
| 83 |  | R3 Admin Meeting 11 | 1h | 2010-11-05 08:00 A | 2010-11-05 09:00 A |  | 100% |  | start no earlier than 2010-11-05 08:00 |
| 84 |  | R3 Admin Meeting 12 | 1h | 2010-11-12 08:00 A | 2010-11-12 09:00 A |  | 100% |  | start no earlier than 2010-11-12 08:00 |
| 85 |  | R3 Admin Meeting 13 | 1h | 2010-11-19 08:00 A | 2010-11-19 09:00 A |  | 100% |  | start no earlier than 2010-11-19 08:00 |
| 86 |  | R3 Admin Meeting 14 | 1h | 2010-11-26 08:00 A | 2010-11-26 09:00 A |  | 100% |  | start no earlier than 2010-11-26 08:00 |
| 87 |  | R3 Admin Meeting 15 | 1h | 2010-12-03 08:00 A | 2010-12-03 09:00 A |  | 100% |  | start no earlier than 2010-12-03 08:00 |
| 88 |  | R3 Admin Meeting 16 | 1h | 2010-12-10 08:00 A | 2010-12-10 09:00 A |  | 100% |  | start no earlier than 2010-12-10 08:00 |
| 89 |  | R3 Admin Meeting 17 | 1h | 2010-12-17 08:00 A | 2010-12-17 09:00 A |  | 100% |  | start no earlier than 2010-12-17 08:00 |
| 90 |  | R3 Admin Meeting 20 | 1h | 2011-01-07 08:00 A | 2011-01-07 09:00 A |  | 100% |  | start no earlier than 2011-01-07 08:00 |
| 91 |  | R3 Admin Meeting 21 | 1h | 2011-01-14 08:00 A | 2011-01-14 09:00 A |  | 100% |  | start no earlier than 2011-01-14 08:00 |
| 92 |  | R3 Admin Meeting 22 | 1h | 2011-01-21 08:00 A | 2011-01-21 09:00 A |  | 100% |  | start no earlier than 2011-01-21 08:00 |
| 93 |  | Communicate cut-over plan | 1h | 2010-11-24 16:00 A | 2010-11-24 17:00 A | 29 | 100% |  |  |
| 94 |  | Schedule Lessons Learned meeting | 1h | 2011-01-20 08:00 A | 2011-01-20 09:00 A | 271FS+25d | 100% |  |  |
| 95 | 3 | **Develop SAP SP Unit Test db** | 24.83d | 2010-08-23 08:00 A | 2010-09-24 15:40 A |  | 100% |  |  |
| 96 |  | Schedule meeting with developer team lead | 1h | 2010-09-09 10:40 A | 2010-09-09 11:40 A | 12 | 100% |  |  |
| 97 |  | Define reuirements | 1d | 2010-08-23 08:00 A | 2010-08-23 17:00 A |  | 100% |  |  |
| 98 |  | SAP SP Unit Test db meeting | 2h | 2010-09-13 11:40 A | 2010-09-13 14:40 A | 96FS+2d | 100% |  |  |
| 99 |  | Assign developer | 1h | 2010-09-13 14:40 A | 2010-09-13 15:40 A | 98 | 100% |  |  |
| 100 |  | Develop SAP SP Unit db | 9d | 2010-09-13 15:40 A | 2010-09-24 15:40 A | 99 | 100% |  |  |
| 101 | 4 | **Test Planning** | 40.5d | 2010-09-03 09:00 A | 2010-10-29 14:00 A |  | 100% |  |  |
| 102 |  | Define, document, communicate test case management procedure - templates, process, … | 4d | 2010-09-03 09:00 A | 2010-09-09 09:00 A | 2 | 100% |  |  |
| 103 | 4.2 | **Unit Test Planning (UT)** | 30.33d | 2010-09-03 09:00 A | 2010-10-15 11:40 A | 102 | 100% |  |  |
| 104 |  | Execute SAP Transaction/Program usage report | 10d | 2010-09-03 09:00 A | 2010-09-17 09:00 A | 2 | 100% |  |  |
| 105 |  | Mirge usage report into SAP SP Unit Test db | 4h | 2010-09-24 15:40 A | 2010-09-27 10:40 A | 95 | 100% |  |  |
| 106 |  | Determine transactions / reports to be tested | 13d | 2010-09-27 10:40 A | 2010-10-14 10:40 A | 105 | 100% |  |  |
| 107 |  | Update SAP SP Unit Test db | 1d | 2010-10-14 10:40 A | 2010-10-15 10:40 A | 106 | 100% |  |  |
| 108 |  | Publish Unit test plan | 1h | 2010-10-15 10:40 A | 2010-10-15 11:40 A | 107 | 100% |  |  |
| 109 | 4.3 | **Update Quality Center (QC) test script catalogs** | 26d | 2010-09-09 09:00 A | 2010-10-15 09:00 A | 102 | 100% |  |  |
| 110 |  | Convert SIT/UAT cases into QC | 20d | 2010-09-09 09:00 A | 2010-10-07 09:00 A |  | 100% |  |  |
| 111 |  | Review transaction / report log for new items | 5d | 2010-09-09 09:00 A | 2010-09-16 09:00 A |  | 100% |  |  |
| 112 |  | Update test script catalog with new transactions / reports | 5d | 2010-09-16 09:00 A | 2010-09-23 09:00 A | 111 | 100% |  |  |
| 113 |  | Review test script catalog for missing / old test scripts | 2d | 2010-09-23 09:00 A | 2010-09-27 09:00 A | 112 | 100% |  |  |
| 114 |  | Create new / update old test scripts | 25d | 2010-09-09 09:00 A | 2010-10-14 09:00 A | 102 | 100% |  |  |
| 115 |  | Convert test cases to new template | 25d | 2010-09-09 09:00 A | 2010-10-14 09:00 A | 102 | 100% |  |  |
| 116 |  | Financial Team confirms completeness of test script catalog | 1d | 2010-10-14 09:00 A | 2010-10-15 09:00 A | 115 | 100% |  |  |
| 117 |  | Logistics Team confirms completeness of test script catalog | 1d | 2010-10-14 09:00 A | 2010-10-15 09:00 A | 115 | 100% |  |  |
| 118 |  | EHS Team confirms completeness of test script catalog | 1d | 2010-10-14 09:00 A | 2010-10-15 09:00 A | 115 | 100% |  |  |
| 119 |  | HR-Payroll Team confirms completeness of test script catalog | 1d | 2010-10-14 09:00 A | 2010-10-15 09:00 A | 115 | 100% |  |  |
| 120 |  | Provide QA w/ FI/LOG/EHS QC user list | 1d | 2010-10-14 09:00 A | 2010-10-15 09:00 A | 115 | 100% |  |  |
| 121 |  | Provide QA w/ HRP QC user list | 1d | 2010-10-14 09:00 A | 2010-10-15 09:00 A | 115 | 100% |  |  |
| 122 | 4.4 | **Systems Integration Test Planning (SIT)** | 36.5d | 2010-09-09 09:00 A | 2010-10-29 14:00 A | 109SS | 100% |  |  |
| 123 |  | Send UA test script calatlog to business owners | 4h | 2010-09-09 09:00 A | 2010-09-09 14:00 A |  | 100% |  |  |
| 124 |  | Function Test Leads meet with Functional Areas to review/plan testing (repetitive) | 30d | 2010-09-09 14:00 A | 2010-10-21 14:00 A | 123 | 100% |  |  |
| 125 |  | Define business scenarios/tests to be used in SIT (add to QC test lab) | 30d | 2010-09-09 14:00 A | 2010-10-21 14:00 A | 123 | 100% |  |  |
| 126 |  | Update business scenarios as required | 2d | 2010-10-21 14:00 A | 2010-10-25 14:00 A | 125 | 100% |  |  |
| 127 |  | QA review of test lab selections | 2d | 2010-10-25 14:00 A | 2010-10-27 14:00 A | 126 | 100% |  |  |
| 128 | 4.4.6 | **Functional Teams confirm test plan** | 1d | 2010-10-25 14:00 A | 2010-10-26 14:00 A | 126 | 100% |  |  |
| 129 |  | Financial Team confirms completeness of business scenarios | 1d | 2010-10-25 14:00 A | 2010-10-26 14:00 A | 126 | 100% |  |  |
| 130 |  | Logistics Team confirms completeness of business scenarios | 1d | 2010-10-25 14:00 A | 2010-10-26 14:00 A | 126 | 100% |  |  |
| 131 |  | EHS Team confirms completeness of business scenarios | 1d | 2010-10-25 14:00 A | 2010-10-26 14:00 A | 126 | 100% |  |  |
| 132 |  | HR-Payroll Team confirms completeness of business scenarios | 1d | 2010-10-25 14:00 A | 2010-10-26 14:00 A | 126 | 100% |  |  |
| 133 |  | QA confirms completeness of business scenarios | 1d | 2010-10-25 14:00 A | 2010-10-26 14:00 A | 126 | 100% |  |  |
| 134 |  | Publish SIT Test Schedule | 1d | 2010-10-26 14:00 A | 2010-10-27 14:00 A | 133 | 100% |  |  |
| 135 | 4.4.9 | **User Acceptance of SIT Planning** | 2d | 2010-10-27 14:00 A | 2010-10-29 14:00 A | 134 | 100% |  |  |
| 136 |  | Send UA test script catalog to business owners | 4h | 2010-10-27 14:00 A | 2010-10-28 09:00 A |  | 100% |  |  |
| 137 |  | Business analysts update test script catalogs | 4h | 2010-10-29 09:00 A | 2010-10-29 14:00 A | 136FS+1d | 100% |  |  |
| 138 | 5 | **System Admin Preparation** | 15.5d | 2010-09-15 10:40 A | 2010-10-06 15:40 A | 15FS+10d | 100% |  |  |
| 139 |  | Review and update action log from previous year | 1d | 2010-09-15 10:40 A | 2010-09-16 10:40 A |  | 100% |  |  |
| 140 |  | Download HRP SP OSS Note Lists (15-26) | 1d | 2010-09-15 10:40 A | 2010-09-16 10:40 A |  | 100% |  |  |

| ID | WBS | Task | Duration | Start | Finish | Predecessors | Complete | Constraint |
| --- | --- | --- | --- | --- | --- | --- | --- | --- |
| 141 |  | Format SP OSS Note Lists into a single spreadsheet and post on wiki | 4h | 2010-09-16 10:40 A | 2010-09-16 15:40 A | 140 | 100% |  |
| 142 |  | Solution Manager Update - SM1 sandbox (SPS Level 21 -> SPS Level 24) | 3d | 2010-09-15 10:40 A | 2010-09-20 10:40 A |  | 100% |  |
| 143 |  | Solution Manager Update - SM2 dev/test (SPS Level 21 -> SPS Level 24) | 3d | 2010-09-20 10:40 A | 2010-09-23 10:40 A | 142 | 100% |  |
| 144 |  | Solution Manager Update - PSM production (SPS Level 21 -> SPS Level 24) | 2d | 2010-09-23 10:40 A | 2010-09-27 10:40 A | 143 | 100% |  |
| 145 |  | Produce Side Effects Report | 2d | 2010-10-04 15:40 A | 2010-10-06 15:40 A | 141FS+12d | 100% |  |
| 146 |  | Download Enh Packs, SP Stacks, SPs | 2d | 2010-10-04 15:40 A | 2010-10-06 15:40 A | 145SS | 100% |  |
| 147 | 6 | **Practice update (SF7)** | 17.5d | 2010-09-20 10:40 A | 2010-10-13 15:40 A | 138SS+3d | 100% |  |
| 148 |  | Identify & Prepare practice system | 13d | 2010-09-20 10:40 A | 2010-10-07 10:40 A |  | 100% |  |
| 149 |  | Apply SAP kernel update | 4h | 2010-10-07 10:40 A | 2010-10-07 15:40 A | 148 | 100% |  |
| 150 |  | Upgrade Oracle db | 8h | 2010-10-07 15:40 A | 2010-10-08 15:40 A | 149 | 100% |  |
| 151 |  | Test Install Support Packs 15-26 (Stacks 7 + SP25 + SP26) | 3d | 2010-10-08 15:40 A | 2010-10-13 15:40 A | 150 | 100% |  |
| 152 |  | PS Snapshot for SF3 (10/04/2010) | 1d | 2010-10-04 08:00 A | 2010-10-04 17:00 A |  | 100% | must start on 2010-10-04 08:00 |
| 153 | 8 | **Cleanup pending transports (to be moved before freeze)** | 15d | 2010-10-07 13:40 A | 2010-10-28 13:40 A | 42FS+20d | 100% |  |
| 154 |  | Create transport list | 1d | 2010-10-07 13:40 A | 2010-10-08 13:40 A | 6 | 100% |  |
| 155 |  | Determine status and plan for each | 3d | 2010-10-07 13:40 A | 2010-10-12 13:40 A | 6 | 100% |  |
| 156 |  | Execute pending transport plan | 12d | 2010-10-12 13:40 A | 2010-10-28 13:40 A | 155 | 100% |  |
| 157 | 9 | **Refresh Staging Environment (SF3)** | 7.62d | 2010-10-08 08:00 A | 2010-10-19 14:00 A |  | 100% |  |
| 158 |  | Notify SAP Support Teams of Pending SF3 Outage | 1h | 2010-10-08 08:00 A | 2010-10-08 09:00 A | 152FS+3d | 100% |  |
| 159 |  | SF3 out of service/SF8 becomes system for OSS staging environment | 0h | 2010-10-09 17:00 A | 2010-10-09 17:00 A | 152FS+15d | 100% |  |
| 160 |  | Holiday (Columbus Day) | 0h | 2010-10-11 17:00 A | 2010-10-11 17:00 A |  | 100% | must finish on 2010-10-11 17:00 |
| 161 |  | Refresh with 10/04/2010 PS1 Snapshot | 4d | 2010-10-11 08:00 A | 2010-10-14 17:00 A | 159 | 100% |  |
| 162 |  | Import PS1/SF3 Transport Gap (10/5-10/15) | 4h | 2010-10-15 08:00 A | 2010-10-15 12:00 A | 161 | 100% |  |
| 163 |  | Execute R3 Action Log | 4h | 2010-10-15 13:00 A | 2010-10-15 17:00 A | 162 | 100% |  |
| 164 |  | Unlock Action Log participants | 1h | 2010-10-18 08:00 A | 2010-10-18 09:00 A | 163 | 100% |  |
| 165 |  | Execute Refresh Action Log | 4h | 2010-10-18 08:00 A | 2010-10-18 12:00 A | 164 | 100% |  |
| 166 |  | Scramble sensitive data <hold off scrambling - perform after py sim run post SF3 upgrade> | 0d | 2010-10-18 12:00 A | 2010-10-18 12:00 A | 165 | 100% |  |
| 167 |  | Execute pre-upgrade payroll simulation run (ZM) & store results (for comparison) | 1d | 2010-10-18 13:00 A | 2010-10-19 12:00 A | 166 | 100% |  |
| 168 |  | Lock Action Log participants | 1h | 2010-10-19 13:00 A | 2010-10-19 14:00 A | 167 | 100% |  |
| 169 | 10 | **Obtain Final Support Pack** | 2d | 2010-10-14 08:00 A | 2010-10-15 17:00 A |  | 100% |  |
| 170 |  | October support pack available from SAP | 1d | 2010-10-14 08:00 A | 2010-10-14 17:00 A |  | 100% | must start on 2010-10-14 08:00 |
| 171 |  | Download support pack & most current SAP kernel patch | 1d | 2010-10-15 08:00 A | 2010-10-15 17:00 A | 170 | 100% |  |
| 172 |  | PS1 Snapshot for Test Environment (SH3 - 10/18/2010) | 1d | 2010-10-18 08:00 A | 2010-10-18 17:00 A |  | 100% | must start on 2010-10-18 08:00 |
| 173 | 12 | **Update Pre-staging Environment (SFK)** | 4d | 2010-10-18 21:00 A | 2010-10-22 17:00 A | 169FS+1d | 100% |  |
| 174 |  | Apply SAP kernel update (114) | 4h | 2010-10-19 08:00 A | 2010-10-19 12:00 A |  | 100% |  |
| 175 |  | Upgrade Oracle db | 0h | 2010-10-18 21:00 A | 2010-10-19 05:00 A | 174 | 100% |  |
| 176 |  | Install Support packages ( SP Stacks 7 + SP 25-27) | 36h | 2010-10-19 05:00 A | 2010-10-20 17:00 A | 175 | 100% |  |
| 177 |  | Update ancillary systems (Portal - SPS 7; PI-ADS - OSS Notes) | 1d | 2010-10-21 08:00 A | 2010-10-21 17:00 A | 176 | 100% |  |
| 178 |  | Validate security infrastructure (SNC) | 2d | 2010-10-21 08:00 A | 2010-10-22 17:00 A | 176 | 100% |  |
| 179 |  | Validate SAPGui interactions | 2d | 2010-10-21 08:00 A | 2010-10-22 17:00 A | 176 | 100% |  |
| 180 |  | Validate basic SAP functions work | 2d | 2010-10-21 08:00 A | 2010-10-22 17:00 A | 176 | 100% |  |
| 181 |  | SFK updated | 0h | 2010-10-22 17:00 A | 2010-10-22 17:00 A |  | 100% | must finish on 2010-10-22 17:00 |
| 182 | 13 | **Update Staging Environment (SF3)** | 6d | 2010-10-25 08:00 A | 2010-11-01 17:00 A | 181 | 100% |  |
| 183 |  | Apply SAP kernel update (114) | 2h | 2010-10-25 08:00 A | 2010-10-25 10:00 A | 181 | 100% |  |
| 184 |  | Install Support packages (SP Stacks 7 + SP 25-27) | 22h | 2010-10-26 12:00 A | 2010-10-27 10:00 A | 183 | 100% |  |
| 185 |  | Upgrade Oracle db | 8h | 2010-10-27 10:00 A | 2010-10-28 10:00 A | 184 | 100% |  |
| 186 |  | Back up SF3 | 2h | 2010-10-28 10:00 A | 2010-10-28 12:00 A | 185 | 100% |  |
| 187 |  | Update BSI (TUBs 183-187) | 2h | 2010-10-26 12:00 A | 2010-10-26 14:00 A | 184SS | 100% |  |
| 188 |  | Update ancillary systems (Portal - SPS 7; PI-ADS - OSS Notes) | 1d | 2010-10-27 10:00 A | 2010-10-28 10:00 A | 184 | 100% |  |
| 189 |  | Produce SPAU report, Apply OSS notes | 1d | 2010-10-27 10:00 A | 2010-10-28 10:00 A | 184 | 100% |  |
| 190 |  | Post Support pack action log | 4h | 2010-10-26 14:00 A | 2010-10-27 09:00 A | 187 | 100% |  |
| 191 |  | Validate - external interfaces ITS, jco, mitid, fax. | 6h | 2010-10-27 09:00 A | 2010-10-27 16:00 A | 190 | 100% |  |
| 192 |  | Unlock Developers involved in SPAU analysis | 1h | 2010-10-27 16:00 A | 2010-10-27 17:00 A | 191 | 100% |  |
| 193 |  | Check, decide, apply MIT mods or use enhancement framework | 2d | 2010-10-28 08:00 A | 2010-10-29 17:00 A | 191FS+1d | 100% |  |
| 194 |  | SAP developer functionality validation | 2d | 2010-10-28 08:00 A | 2010-10-29 17:00 A | 193SS | 100% |  |
| 195 |  | Execute post-upgrade payroll simulation run (ZM) & compare results | 1d | 2010-11-01 08:00 A | 2010-11-01 17:00 A | 193 | 100% |  |
| 196 |  | Execute post-upgrade DW extracts (limited testing - key extracts) | 1d | 2010-11-01 08:00 A | 2010-11-01 17:00 A | 193 | 100% |  |
| 197 |  | SF3 updated | 0h | 2010-11-01 17:00 A | 2010-11-01 17:00 A |  | 100% | must finish on 2010-11-01 17:00 |
| 198 |  | Development freeze begins (non-SP development is put on hold) | 0h | 2010-11-01 17:00 A | 2010-11-01 17:00 A | 182 | 100% |  |
| 199 | 15 | **Update Development Environment (SF2)** | 2d | 2010-11-01 17:00 A | 2010-11-03 17:00 A | 198 | 100% |  |
| 200 |  | Apply SAP kernel update (114) | 4h | 2010-11-01 17:00 A | 2010-11-01 21:00 A |  | 100% |  |
| 201 |  | Install Support packages (SP Stacks 7 + SP 25-27) | 12h | 2010-11-01 17:00 A | 2010-11-02 05:00 A |  | 100% |  |
| 202 |  | Apply BSI Tax Factory Update | 2h | 2010-11-02 08:00 A | 2010-11-02 10:00 A | 201 | 100% |  |
| 203 |  | Upgrade ERP Oracle db | 8h | 2010-11-02 05:00 A | 2010-11-02 13:00 A | 202 | 100% |  |
| 204 |  | Back up database | 6h | 2010-11-02 13:00 A | 2010-11-03 10:00 A | 203 | 100% |  |
| 205 |  | Import transports from SF3 | 2h | 2010-11-02 10:00 A | 2010-11-02 12:00 A |  | 100% |  |
| 206 | 15.7 | **Upgrade Portal (JP3)** | 1d | 2010-11-02 13:00 A | 2010-11-03 12:00 A | 205 | 100% |  |
| 207 |  | Apply SPS 7 | 6h | 2010-11-02 13:00 A | 2010-11-03 10:00 A |  | 100% |  |
| 208 |  | Upgrade Portal Oracle db | 8h | 2010-11-02 13:00 A | 2010-11-03 12:00 A |  | 100% |  |
| 209 | 15.8 | **Upgrade PI/ADS System (J11)** | 1d | 2010-11-02 08:00 A | 2010-11-02 17:00 A |  | 100% |  |
| 210 |  | Upgrade kernel | 1h | 2010-11-02 08:00 A | 2010-11-02 09:00 A |  | 100% |  |

| ID | WBS | Task | Duration | Start | Finish | Predecessors | Complete | Total float | Constraint |
| --- | --- | --- | --- | --- | --- | --- | --- | --- | --- |
| 211 |  | Apply SPS 7 | 6h | 2010-11-02 08:00 A | 2010-11-02 15:00 A |  | 100% |  |  |
| 212 |  | Upgrade PI/ADS Oracle db (J01) | 8h | 2010-11-02 08:00 A | 2010-11-02 17:00 A |  | 100% |  |  |
| 213 |  | Execute action log (add updates if necessary) | 4h | 2010-11-02 13:00 A | 2010-11-02 17:00 A | 207 | 100% |  |  |
| 214 |  | SF2 updated | 0h | 2010-11-03 17:00 A | 2010-11-03 17:00 A |  | 100% |  | must finish on 2010-11-03 17:00 |
| 215 | 16 | **Zuttreq updates** | 0.12d | 2010-11-04 08:00 A | 2010-11-04 09:00 A | 199 | 100% |  |  |
| 216 |  | Change target system for transport layer | 1h | 2010-11-04 08:00 A | 2010-11-04 09:00 A |  | 100% |  |  |
| 217 |  | Change target system in Zuttreq | 1h | 2010-11-04 08:00 A | 2010-11-04 09:00 A |  | 100% |  |  |
| 218 | 17 | **Unit Test Execution (performed in SF2)** | 5d | 2010-11-04 08:00 A | 2010-11-10 17:00 A | 199 | 100% |  |  |
| 219 | 17.1 | **Functional Tests** | 5d | 2010-11-04 08:00 A | 2010-11-10 17:00 A |  | 100% |  |  |
| 220 |  | Financial Unit Tests, Issue identification and retest | 5d | 2010-11-04 08:00 A | 2010-11-10 17:00 A |  | 100% |  |  |
| 221 |  | Logistics Unit Tests, Issue identification and retest | 5d | 2010-11-04 08:00 A | 2010-11-10 17:00 A |  | 100% |  |  |
| 222 |  | EHS Unit Tests, Issue identification and retest | 5d | 2010-11-04 08:00 A | 2010-11-10 17:00 A |  | 100% |  |  |
| 223 |  | HR-Payroll Unit Tests, Issue identification and retest | 5d | 2010-11-04 08:00 A | 2010-11-10 17:00 A |  | 100% |  |  |
| 224 |  | All functional teams ok environment and move to SIT | 4h | 2010-11-10 13:00 A | 2010-11-10 17:00 A | 219FF | 100% |  |  |
| 225 |  | Unit test complete | 0h | 2010-11-10 17:00 A | 2010-11-10 17:00 A | 224 | 100% |  |  |
| 226 | 18 | **Refresh Test Environment (SH3)** | 7.25d | 2010-10-28 08:00 A | 2010-11-08 10:00 A | 193SS | 100% |  |  |
| 227 |  | Pre-update DW extracts (store for comparisons - from PS1) | 4h | 2010-10-28 08:00 A | 2010-10-28 12:00 A |  | 100% |  |  |
| 228 |  | Confirm/Setup/update gateway components for new test system | 4h | 2010-10-28 08:00 A | 2010-10-28 12:00 A |  | 100% |  |  |
| 229 |  | Refresh with 10/18/2010 PS1 Snapshot | 30h | 2010-10-28 08:00 A | 2010-11-02 15:00 A |  | 100% |  |  |
| 230 |  | Post Restore Activities | 2d | 2010-11-02 15:00 A | 2010-11-04 15:00 A | 229 | 100% |  |  |
| 231 |  | Import PS1/SH3 Transport Gap (10/19-11/5) | 4h | 2010-11-04 15:00 A | 2010-11-05 10:00 A | 230 | 100% |  |  |
| 232 |  | Execute R3 Action Log | 4h | 2010-11-05 10:00 A | 2010-11-05 15:00 A | 231 | 100% |  |  |
| 233 |  | Execute Refresh Action Log | 4h | 2010-11-05 15:00 A | 2010-11-08 10:00 A | 232 | 100% |  |  |
| 234 | 19 | **Update Test Environment (SH3)** | 4d | 2010-11-05 08:00 A | 2010-11-10 19:00 A | 199FS+1d | 100% |  |  |
| 235 |  | Apply SAP kernel update (114) | 2h | 2010-11-08 10:00 A | 2010-11-08 12:00 A | 233 | 100% |  |  |
| 236 |  | Install Support packages (SP Stacks 7 + SP 25-27) | 12h | 2010-11-08 12:00 A | 2010-11-09 00:00 A | 235 | 100% |  |  |
| 237 |  | Apply BSI Tax Factory Update | 2h | 2010-11-09 00:00 A | 2010-11-09 02:00 A | 236 | 100% |  |  |
| 238 |  | Import transports from SF3 | 2h | 2010-11-09 02:00 A | 2010-11-09 04:00 A | 237 | 100% |  |  |
| 239 |  | Upgrade Oracle db | 8h | 2010-11-09 04:00 A | 2010-11-09 12:00 A | 238 | 100% |  |  |
| 240 |  | Back up database | 6h | 2010-11-09 13:00 A | 2010-11-10 10:00 A | 239 | 100% |  |  |
| 241 |  | Execute post support pack action log (add updates if necessary) | 4h | 2010-11-10 10:00 A | 2010-11-10 15:00 A | 240 | 100% |  |  |
| 242 |  | Import transports from SF2 | 2h | 2010-11-10 17:00 A | 2010-11-10 19:00 A | 225 | 100% |  |  |
| 243 |  | Import Production Transports from 11/9 | 2h | 2010-11-10 10:00 A | 2010-11-10 12:00 A | 240 | 100% |  |  |
| 244 |  | DW Schedule Extract Jobs | 1h | 2010-11-10 15:00 A | 2010-11-10 16:00 A | 241 | 100% |  |  |
| 245 | 19.11 | **Upgrade Portal (JP5)** | 1d | 2010-11-05 08:00 A | 2010-11-05 17:00 A |  | 100% |  |  |
| 246 |  | Apply SPS 7 | 6h | 2010-11-05 08:00 A | 2010-11-05 15:00 A |  | 100% |  |  |
| 247 |  | Upgrade Portal Oracle db | 8h | 2010-11-05 08:00 A | 2010-11-05 17:00 A |  | 100% |  |  |
| 248 | 19.12 | **Upgrade PI/ADS System** | 1d | 2010-11-05 08:00 A | 2010-11-05 17:00 A |  | 100% |  |  |
| 249 |  | Update kernel | 1h | 2010-11-05 08:00 A | 2010-11-05 09:00 A |  | 100% |  |  |
| 250 |  | Apply SPS 7 | 6h | 2010-11-05 08:00 A | 2010-11-05 15:00 A |  | 100% |  |  |
| 251 |  | Upgrade PI/ADS Oracle db | 8h | 2010-11-05 08:00 A | 2010-11-05 17:00 A |  | 100% |  |  |
| 252 |  | Production Transport Freeze Begins (last transports allowed into PS1) | 0d | 2010-11-10 19:00 A | 2010-11-10 19:00 A | 234 | 100% |  |  |
| 253 | 21 | **Execute System Integration Tests (SH3)** | 21.5d | 2010-11-11 08:00 A | 2010-12-10 12:00 A | 218 | 100% |  |  |
| 254 |  | Holiday (Veterans Day) | 0d | 2010-11-11 17:00 A | 2010-11-11 17:00 A | 252FS+1d | 100% |  |  |
| 255 |  | Execute Payroll comparison run | 5d | 2010-11-11 08:00 A | 2010-11-17 17:00 A |  | 100% |  |  |
| 256 |  | Execute data warehouse extracts | 1d | 2010-11-12 08:00 A | 2010-11-12 17:00 A | 255SS+1d | 100% |  |  |
| 257 |  | Analyze data warehouse extracts comparison | 1d | 2010-11-15 08:00 A | 2010-11-15 17:00 A | 256 | 100% |  |  |
| 258 |  | Analyze payroll comparison run | 3d | 2010-11-18 08:00 A | 2010-11-22 17:00 A | 255 | 100% |  |  |
| 259 |  | Financial Close (month of October) | 1d | 2010-11-18 08:00 A | 2010-11-18 17:00 A | 255 | 100% |  |  |
| 260 |  | Execute Automated Testing | 1d | 2010-11-18 08:00 A | 2010-11-18 17:00 A | 255 | 100% |  |  |
| 261 |  | Execute General SIT | 12d | 2010-11-19 08:00 A | 2010-12-06 17:00 A | 260 | 100% |  |  |
| 262 |  | Issue Retesting | 2d | 2010-12-07 08:00 A | 2010-12-08 17:00 A | 261 | 100% |  |  |
| 263 |  | Execute pre-update validation testing | 1d | 2010-12-08 08:00 A | 2010-12-08 17:00 A | 261FS+1d | 100% |  |  |
| 264 |  | System Integration Test sign-off | 4h | 2010-12-09 08:00 A | 2010-12-09 12:00 A | 263 | 100% |  |  |
| 265 |  | SIT complete | 0h | 2010-12-09 12:00 A | 2010-12-09 12:00 A | 264 | 100% |  |  |
| 266 |  | Final preparation work | 1d | 2010-12-09 13:00 A | 2010-12-10 12:00 A | 265 | 100% |  |  |
| 267 | 22 | **Pre-cutover weekend activities** | 0.12d | 2010-12-02 13:00 A | 2010-12-02 14:00 A | 271SS-6d | 100% |  |  |
| 268 |  | System message put out on SAP GUI | 1h | 2010-12-02 13:00 A | 2010-12-02 14:00 A |  | 100% |  |  |
| 269 |  | System message put out on SAPWeb & ESS&insideMIT pages | 1h | 2010-12-02 13:00 A | 2010-12-02 14:00 A |  | 100% |  |  |
| 270 |  | Send outage headsup message to community | 1h | 2010-12-02 13:00 A | 2010-12-02 14:00 A |  | 100% |  |  |
| 271 | 23 | **Cutover weekend & Controlled Start** | 3.5d | 2010-12-10 12:00 A | 2010-12-15 17:00 A |  | 100% |  |  |
| 272 |  | Update production (detailed weekend cutover plan in a separate document) | 2d | 2010-12-10 12:00 A | 2010-12-11 04:00 A | 253 | 100% |  |  |
| 273 |  | Production validation | 1d | 2010-12-11 12:00 A | 2010-12-11 20:00 A | 272FS+1d | 100% |  |  |
| 274 |  | Go/No Go approval | 1h | 2010-12-11 20:00 A | 2010-12-11 21:00 A | 273 | 100% |  |  |
| 275 |  | Updated production available | 0h | 2010-12-11 21:00 A | 2010-12-11 21:00 A | 274 | 100% |  |  |
| 276 |  | First Production pay run execution | 2d | 2010-12-14 08:00 A | 2010-12-15 17:00 A | 275FS+1d | 100% |  |  |
| 277 |  | Freezes End (development & production) | 0h | 2010-12-15 17:00 A | 2010-12-15 17:00 A | 276 | 100% |  |  |
| 278 |  | First Calendar 2011 Payroll | 1d | 2010-12-22 08:00 A | 2010-12-22 17:00 A |  | 100% |  | must finish on 2010-12-22 17:00 |
| 279 | 26 | **Post go-live activities** | 33.12d | 2010-12-16 08:00 A | 2011-02-01 09:00 |  | 98% | 0d |  |
| 280 |  | Install SAP GUI level 16 on EHS PCs (see RT # 1397279) | 2h | 2010-12-16 08:00 | 2010-12-16 10:00 | 277 |  | 32.88d |  |

| ID | Task | Duration | Start | Finish | Predecessors | Complete | Total float |
| --- | --- | --- | --- | --- | --- | --- | --- |
| 281 | SH3 Status Change | 1h | 2010-12-16 08:00 A | 2010-12-16 09:00 A | 277 | 100% |  |
| 282 | SH1 Status Change | 1h | 2010-12-16 08:00 A | 2010-12-16 09:00 A | 277 | 100% |  |
| 283 | SF5 Status Change | 1h | 2010-12-16 08:00 A | 2010-12-16 09:00 A | 277 | 100% |  |
| 284 | Scramble SF3 | 4h | 2010-12-16 08:00 | 2010-12-16 12:00 | 277 |  | 32.62d |
| 285 | PS1 Snapshot for SF5/SF8/SH1 | 1h | 2010-12-30 08:00 A | 2010-12-30 09:00 A | 277FS+10d | 100% |  |
| 286 | SF5 System refresh & update | 10d | 2010-12-30 09:00 A | 2011-01-13 09:00 A | 285 | 100% |  |
| 287 | SH1 System refresh & update | 10d | 2011-01-13 09:00 A | 2011-01-27 09:00 A | 286 | 100% |  |
| 288 | Zuttreq updates | 1h | 2011-01-27 09:00 A | 2011-01-27 10:00 A | 287 | 100% |  |
| 289 | Change target system in Zuttreq | 1h | 2011-01-13 09:00 A | 2011-01-13 10:00 A | 286 | 100% |  |
| 290 | SF8 System Refresh & Update | 10d | 2011-01-18 09:00 A | 2011-02-01 09:00 A | 286FS+3d | 100% |  |

## Version 2 (saved 2011-02-13)

Last finish stays 2011-02-01. Complete tasks 249 → 250.

Changed:

| ID | Task | Start | Finish | Complete | Total float |
| --- | --- | --- | --- | --- | --- |
| 31 | **Communication** |  | 2011-01-26 10:00 A | 99% → 100% | 3.88d → none |
| 66 | **SAPbiz Meeting** |  | 2011-01-26 10:00 A | 80% → 100% | 3.88d → none |
| 71 | SAPbiz Meeting 5 | 2011-01-26 08:00 A | 2011-01-26 10:00 A | 0% → 100% | 3.88d → none |
